| id | name | startDate | endDate | priority | barScale | progress | type | parentId | dependencies |
| --- | --- | --- | --- | --- | --- | --- | --- | --- | --- |
| 1 | Bathroom Remodel | 2026-06-01T00:00:00.000Z | 2026-07-13T00:00:00.000Z | medium | 1 | 0 | group |  |  |
| 2 | Order materials | 2026-06-01T00:00:00.000Z | 2026-06-04T00:00:00.000Z | high | 1 | 0 | task | 1 |  |
| 3 | Order glass shower door | 2026-06-01T00:00:00.000Z | 2026-06-02T00:00:00.000Z | high | 1 | 0 | milestone | 1 |  |
| 4 | Demolition | 2026-06-04T00:00:00.000Z | 2026-06-06T00:00:00.000Z | medium | 1 | 0 | task | 1 | 2 FS |
| 5 | Plumbing rough-in | 2026-06-08T00:00:00.000Z | 2026-06-11T00:00:00.000Z | medium | 1 | 0 | task | 1 | 4 FS |
| 6 | Electrical rough-in | 2026-06-09T00:00:00.000Z | 2026-06-11T00:00:00.000Z | medium | 1 | 0 | task | 1 |  |
| 7 | Heated floor wires | 2026-06-11T00:00:00.000Z | 2026-06-12T00:00:00.000Z | medium | 1 | 0 | task | 1 |  |
| 8 | Rough inspection | 2026-06-14T00:00:00.000Z | 2026-06-15T00:00:00.000Z | medium | 1 | 0 | milestone | 1 |  |
| 9 | Drywall and backer board | 2026-06-15T00:00:00.000Z | 2026-06-18T00:00:00.000Z | medium | 1 | 0 | task | 1 | 8 FS |
| 10 | Waterproofing membrane | 2026-06-18T00:00:00.000Z | 2026-06-20T00:00:00.000Z | high | 1 | 0 | task | 1 | 9 FS |
| 11 | Floor tile | 2026-06-22T00:00:00.000Z | 2026-06-25T00:00:00.000Z | medium | 1 | 0 | task | 1 |  |
| 12 | Shower wall tile | 2026-06-25T00:00:00.000Z | 2026-06-29T00:00:00.000Z | medium | 1 | 0 | task | 1 | 11 FS |
| 13 | Grout and seal | 2026-06-29T00:00:00.000Z | 2026-07-01T00:00:00.000Z | medium | 1 | 0 | task | 1 | 12 FS |
| 14 | Vanity install | 2026-07-02T00:00:00.000Z | 2026-07-04T00:00:00.000Z | medium | 1 | 0 | task | 1 |  |
| 15 | Toilet install | 2026-07-04T00:00:00.000Z | 2026-07-05T00:00:00.000Z | medium | 1 | 0 | task | 1 |  |
| 16 | Mirror and lighting | 2026-07-05T00:00:00.000Z | 2026-07-07T00:00:00.000Z | medium | 1 | 0 | task | 1 |  |
| 17 | Plumbing fixtures | 2026-07-06T00:00:00.000Z | 2026-07-08T00:00:00.000Z | medium | 1 | 0 | task | 1 |  |
| 18 | Glass shower door | 2026-07-08T00:00:00.000Z | 2026-07-09T00:00:00.000Z | medium | 1 | 0 | milestone | 1 |  |
| 19 | Caulk and seal | 2026-07-09T00:00:00.000Z | 2026-07-10T00:00:00.000Z | medium | 1 | 0 | task | 1 |  |
| 20 | Final inspection | 2026-07-12T00:00:00.000Z | 2026-07-13T00:00:00.000Z | medium | 1 | 0 | milestone | 1 |  |
